# Plano de TI

Schedule from MS Project, 2020-04-08 to 2020-12-10.
.

## Calendars

- Padrão: Mon-Fri 09:00-12:00, 13:00-18:00; Sat-Sun off.

## Resources

| Resource | Group | Unit |
| --- | --- | --- |
| Marcos Lapa | Contratado |  |
| Rubem de Almeida | Contratado |  |
| Thomas Wicks | Projetos |  |
| Breno Mancini | Contratado |  |
| Pedro Gustavo Santana | Contratado |  |
| Lucas Eduardo | Contratado |  |
| Bruno Guerra | Contratado |  |
| Computador | Equipamento | 6 |

## Schedule

| ID | WBS | Task | Type | Duration | Start | Finish | Predecessors | Total slack | Free slack | Constraint | Resources | Work |
| --- | --- | --- | --- | --- | --- | --- | --- | --- | --- | --- | --- | --- |
| 1 | 1 | **BOMIX Force** |  | 177d | 2020-04-08 | 2020-12-10 |  | 0d |  |  |  | 2670.4h |
| 2 | 1.1 | **Gerenciamento do projeto** |  | 3d | 2020-04-08 | 2020-04-10 |  |  |  |  |  | 184h |
| 3 | 1.1.1 | **Encontro inicial** |  | 1d | 2020-04-08 | 2020-04-08 |  | 168.4d |  |  |  | 112h |
| 4 | 1.1.1.1 | Reunião de Kick-off |  | 1d | 2020-04-08 | 2020-04-08 |  | 168.4d | 0d |  | Breno Mancini; Bruno Guerra; Computador [1 6]; Lucas Eduardo; Marcos Lapa; Pedro Gustavo Santana; Rubem de Almeida; Thomas Wicks | 56h |
| 5 | 1.1.1.2 | Apresentação do Theoprax |  | 1d | 2020-04-08 | 2020-04-08 | 4SS | 168.4d | 0d |  | Breno Mancini; Bruno Guerra; Computador [1 6]; Lucas Eduardo; Marcos Lapa; Pedro Gustavo Santana; Rubem de Almeida; Thomas Wicks | 56h |
| 6 | 1.1.2 | **Plano de projeto** |  | 2d | 2020-04-09 | 2020-04-10 |  | 168.4d |  |  |  | 72h |
| 7 | 1.1.2.1 | Autorização do Projeto |  | 1d | 2020-04-09 | 2020-04-09 | 5 | 168.4d | 0d |  | Breno Mancini; Rubem de Almeida; Thomas Wicks | 24h |
| 8 | 1.1.2.2 | Elaboração do Plano de Projeto |  | 2d | 2020-04-09 | 2020-04-10 | 7SS | 168.4d | 0d |  | Bruno Guerra; Lucas Eduardo; Pedro Gustavo Santana | 48h |
| 9 | 1.2 | **Análise do Sistema** |  | 33d | 2020-04-13 | 2020-05-27 |  | 91.5d |  |  |  | 206.4h |
| 10 | 1.2.1 | **Levantar Dados e Processos** |  | 1d | 2020-04-13 | 2020-04-13 | 7 | 168.4d |  |  |  | 56h |
| 11 | 1.2.1.1 | Reunião de alinhamento |  | 1d | 2020-04-13 | 2020-04-13 | 8 | 168.4d | 0d |  | Bruno Guerra; Lucas Eduardo; Pedro Gustavo Santana; Thomas Wicks | 32h |
| 12 | 1.2.1.2 | Definição do processo |  | 1d | 2020-04-13 | 2020-04-13 | 11SS | 173d |  |  | Breno Mancini; Pedro Gustavo Santana; Rubem de Almeida | 24h |
| 13 | 1.2.2 | **Criação de especificações** |  | 4.6d | 2020-04-14 | 2020-04-20 |  | 168.4d |  |  |  | 110.4h |
| 14 | 1.2.2.1 | Analisar Regras de Negócio e Criar Escopo |  | 1.6d | 2020-04-14 | 2020-04-15 | 11 | 168.4d | 0d |  | Bruno Guerra; Lucas Eduardo; Rubem de Almeida | 38.4h |
| 15 | 1.2.2.2 | Elaborar Especificação Técnica e Funcional |  | 3d | 2020-04-15 | 2020-04-20 | 14 | 168.4d |  |  | Lucas Eduardo; Pedro Gustavo Santana; Thomas Wicks | 72h |
| 16 | 1.2.3 | **Definição do Framework** |  | 1d | 2020-05-26 | 2020-05-26 |  | 60.5d |  |  |  | 24h |
| 17 | 1.2.3.1 | Pesquisa de posíveis opções |  | 0.5d | 2020-05-26 | 2020-05-26 |  | 60.5d | 0d | start no earlier than 2020-05-26 | Breno Mancini; Lucas Eduardo; Pedro Gustavo Santana | 12h |
| 18 | 1.2.3.2 | Definir Framework |  | 0.5d | 2020-05-26 | 2020-05-26 | 17 | 60.5d | 0d |  | Bruno Guerra; Marcos Lapa; Thomas Wicks | 12h |
| 19 | 1.2.4 | **Definição do servidor em nuvem** |  | 1d | 2020-05-27 | 2020-05-27 | 18 | 60.5d |  |  |  | 16h |
| 20 | 1.2.4.1 | Pesquisa de posíveis opções |  | 0.5d | 2020-05-27 | 2020-05-27 |  | 60.5d | 0d |  | Breno Mancini; Pedro Gustavo Santana; Thomas Wicks | 12h |
| 21 | 1.2.4.2 | Definir Framework |  | 0.5d | 2020-05-27 | 2020-05-27 | 20 | 141d |  |  | Thomas Wicks | 4h |
| 22 | 1.2.5 | Análise do sistema concluído | milestone | 0d | 2020-05-27 | 2020-05-27 | 20 | 60.5d | 24.5d |  |  |  |
| 23 | 1.3 | **Desenvolvimento** |  | 112d | 2020-07-01 | 2020-12-03 |  | 0d |  |  |  | 2112h |
| 24 | 1.3.1 | **Programar Módulos para Back-End** |  | 85d | 2020-07-01 | 2020-10-27 |  | 3d | 0d |  |  | 1648h |
| 25 | 1.3.1.1 | Preparação de Ambiente de Desenvolvimento |  | 20d | 2020-07-01 | 2020-07-28 | 22 | 36d | 0d | start no earlier than 2020-07-01 | Rubem de Almeida; Thomas Wicks | 320h |
| 26 | 1.3.1.2 | Módulo de Usuário | manual | 5d | 2020-07-29 | 2020-08-04 | 25 |  |  |  | Breno Mancini; Rubem de Almeida | 80h |
| 27 | 1.3.1.3 | Módulo do Comercial | manual | 20d | 2020-08-05 | 2020-09-01 | 26 |  |  |  | Rubem de Almeida; Thomas Wicks | 320h |
| 28 | 1.3.1.4 | Módulo de Qualidade |  | 7d | 2020-09-02 | 2020-09-10 | 27 | 36d |  |  | Breno Mancini; Thomas Wicks | 112h |
| 29 | 1.3.1.5 | Comunicação com TI |  | 30d | 2020-09-10 | 2020-10-21 | 26SS | 3d | 0d | start no earlier than 2020-09-10 | Breno Mancini; Rubem de Almeida; Thomas Wicks | 720h |
| 30 | 1.3.1.6 | Teste caixa preta |  | 4d | 2020-10-22 | 2020-10-27 | 29 | 3d |  |  | Bruno Guerra; Lucas Eduardo; Pedro Gustavo Santana | 96h |

| ID | WBS | Task | Type | Duration | Start | Finish | Predecessors | Total slack | Constraint | Resources | Work |
| --- | --- | --- | --- | --- | --- | --- | --- | --- | --- | --- | --- |
| 31 | 1.3.2 | **Programar Módulos para Front-End** |  | 27d | 2020-10-28 | 2020-12-03 | 24 | 0d |  |  | 464h |
| 32 | 1.3.2.1 | Preparação de Ambiente de Desenvolvimento |  | 7d | 2020-10-28 | 2020-11-05 | 29 | 3d | start no earlier than 2020-09-08 | Bruno Guerra; Lucas Eduardo | 112h |
| 33 | 1.3.2.2 | Módulo de Usuário. | manual | 2d | 2020-11-11 | 2020-11-12 | 32 |  |  | Lucas Eduardo; Pedro Gustavo Santana | 32h |
| 34 | 1.3.2.3 | Módulo do Comercial |  | 5d | 2020-11-13 | 2020-11-19 | 33 | 0d |  | Bruno Guerra; Pedro Gustavo Santana | 80h |
| 35 | 1.3.2.4 | Módulo de Qualidade. |  | 7d | 2020-11-20 | 2020-11-30 | 34 | 0d |  | Bruno Guerra; Lucas Eduardo; Pedro Gustavo Santana | 168h |
| 36 | 1.3.2.5 | Teste caixa branca |  | 3d | 2020-12-01 | 2020-12-03 | 35 | 0d |  | Breno Mancini; Rubem de Almeida; Thomas Wicks | 72h |
| 37 | 1.3.3 | Sistema Desenvolvido | milestone | 0d | 2020-12-03 | 2020-12-03 | 36 | 0d |  |  |  |
| 38 | 1.4 | **Implantar Sistema em Produção** |  | 5d | 2020-12-04 | 2020-12-10 | 37 | 0d |  |  | 168h |
| 39 | 1.4.1 | **Preparação do ambiente de produção** |  | 4d | 2020-12-04 | 2020-12-09 |  | 0d |  |  | 144h |
| 40 | 1.4.1.1 | Instalar Sistema nas Estações de Trabalho Clientes |  | 4d | 2020-12-04 | 2020-12-09 | 37 | 0d |  | Breno Mancini [150%]; Rubem de Almeida [150%]; Thomas Wicks [150%] | 144h |
| 41 | 1.4.1.2 | Sistema Implantado | milestone | 0d | 2020-12-09 | 2020-12-09 | 40 | 0d | finish no earlier than 2020-04-21 |  |  |
| 42 | 1.4.2 | **Encerramento** |  | 1d | 2020-12-10 | 2020-12-10 |  | 0d |  |  | 24h |
| 43 | 1.4.2.1 | Entrega de documentação do código |  | 1d | 2020-12-10 | 2020-12-10 | 41 | 0d |  | Breno Mancini; Rubem de Almeida; Thomas Wicks | 24h |
| 44 | 1.4.2.2 | Reunião de fechamento | milestone | 0d | 2020-12-10 | 2020-12-10 | 43 | 0d |  | Breno Mancini; Bruno Guerra; Computador; Lucas Eduardo; Marcos Lapa; Pedro Gustavo Santana; Rubem de Almeida; Thomas Wicks |  |
